# MICEMagFieldMitigation

Schedule from MS Project, 2012-10-22 to 2013-11-04.
STFC

## Calendars

- Standard: Mon-Fri 08:00-12:00, 13:00-17:00; Sat-Sun off.

## Resources

| Resource |
| --- |
| JT |
| IM |
| VF |
| TW |
| CM |
| DA |
| PS |
| MC |
| CP |
| All |
| LF |
| TB |
| DP |
| OPUS |
| BPG |
| K-R |
| CMc |
| ISIS |
| Hall |
| JG |
| JW |
| OM |
| ? |
| Contractor |

## Schedule

| ID | WBS | Task | Type | Duration | Start | Finish | Predecessors | Total slack | Free slack | Constraint | Resources | Work |
| --- | --- | --- | --- | --- | --- | --- | --- | --- | --- | --- | --- | --- |
| 1 | 1 | **MICE Magnetic Field Mitigation** |  | 271d? | 2012-10-22 | 2013-11-04 |  | 0d |  |  |  | 6832h |
| 2 | 1.1 | **Model Validation** |  | 5d | 2012-10-22 | 2012-10-26 |  | 261d | 0d |  |  |  |
| 3 | 1.1.1 | Compare AFC field to Model |  | 2d | 2012-10-22 | 2012-10-23 |  | 261d | 0d |  |  |  |
| 4 | 1.1.2 | Compare AFC Rack/Compressor field to model |  | 2d | 2012-10-24 | 2012-10-25 | 3 | 261d | 0d |  |  |  |
| 5 | 1.1.3 | Holgers issue - check low fields develop high magnetization |  | 1d | 2012-10-26 | 2012-10-26 | 4 | 261d |  |  |  |  |
| 6 | 1.2 | **West Wall Compressor Move** |  | 271d? | 2012-10-22 | 2013-11-04 |  | 0d |  |  |  | 4416h |
| 7 | 1.2.1 | **Magnetic modeling of equipment at West wall** |  | 25d | 2012-10-22 | 2012-11-23 |  | 133d |  |  |  | 200h |
| 8 | 1.2.1.1 | Modelling & results |  | 15d | 2012-10-22 | 2012-11-09 |  | 133d | 0d | start no earlier than 2012-10-22 | PS | 120h |
| 9 | 1.2.1.2 | Cross checking |  | 10d | 2012-11-12 | 2012-11-23 | 8 | 133d | 0d |  | MC | 80h |
| 10 | 1.2.1.3 | TB approval & sign off | milestone | 0d | 2012-11-23 | 2012-11-23 | 9 | 133d |  |  | All |  |
| 11 | 1.2.2 | **Design** |  | 148d | 2012-10-22 | 2013-05-15 |  | 55d |  |  |  | 1224h |
| 12 | 1.2.2.1 | High pressure hose routing & support design |  | 20d | 2013-01-07 | 2013-02-01 |  | 0d |  | start no earlier than 2013-01-07 | JT; LF | 320h |
| 13 | 1.2.2.2 | West Wall Mezzanine Concept with South Mezz Stairs |  | 20d | 2013-02-04 | 2013-03-01 | 12 | 0d |  |  | JT; LF | 320h |
| 14 | 1.2.2.3 | SHE & TB Approval |  | 10d | 2013-03-04 | 2013-03-15 | 13 | 0d |  |  | TB | 80h |
| 15 | 1.2.2.4 | Complete | milestone | 0d | 2012-10-22 | 2012-10-22 |  | 271d |  |  |  |  |
| 16 | 1.2.2.5 | **Opus to produce west wall mezz installation drawings** |  | 43d | 2013-03-18 | 2013-05-15 |  | 0d |  |  |  | 504h |
| 17 | 1.2.2.5.1 | RFQ |  | 10d | 2013-03-18 | 2013-03-29 | 14 | 0d |  |  | JT; DP | 160h |
| 18 | 1.2.2.5.2 | Order |  | 3d | 2013-04-01 | 2013-04-03 | 17 | 0d |  |  | DP | 24h |
| 19 | 1.2.2.5.3 | Design |  | 20d | 2013-04-04 | 2013-05-01 | 18 | 0d |  |  | OPUS | 160h |
| 20 | 1.2.2.5.4 | Review & Iteration |  | 10d | 2013-05-02 | 2013-05-15 | 19 | 0d |  |  | JT; DP | 160h |
| 21 | 1.2.2.5.5 | Sign Off / Complete | milestone | 0d | 2013-05-15 | 2013-05-15 | 20 | 0d |  |  | JT; DP |  |
| 22 | 1.2.3 | **West Mezz Build & Associated** |  | 92d | 2013-05-16 | 2013-09-20 |  | 0d |  |  |  | 1152h |
| 23 | 1.2.3.1 | RFQs |  | 10d | 2013-05-16 | 2013-05-29 | 21 | 0d |  |  | JT; DP | 160h |
| 24 | 1.2.3.2 | Orders |  | 5d | 2013-05-30 | 2013-06-05 | 10, 23 | 0d |  |  | DP | 40h |
| 25 | 1.2.3.3 | Contractor Lag |  | 30d | 2013-06-06 | 2013-07-17 | 24 | 20d | 0d |  | BPG | 240h |
| 26 | 1.2.3.4 | Modification of South Mezz Stairs |  | 10d | 2013-07-18 | 2013-07-31 | 25 | 20d |  |  | K-R | 80h |
| 27 | 1.2.3.5 | Manufacture - Purchase of other parts |  | 60d | 2013-06-06 | 2013-08-28 | 24 | 0d |  |  | K-R | 480h |
| 28 | 1.2.3.6 | Installation |  | 15d | 2013-08-29 | 2013-09-18 | 26, 27 | 0d |  |  | K-R | 120h |
| 29 | 1.2.3.7 | Load Test? Inspection |  | 2d | 2013-09-19 | 2013-09-20 | 28 | 0d |  |  | JT; DP | 32h |
| 30 | 1.2.3.8 | Sign Off / Complete | milestone | 0d | 2013-09-20 | 2013-09-20 | 29 | 0d |  |  | JT; DP |  |

| ID | WBS | Task | Type | Duration | Start | Finish | Predecessors | Total slack | Free slack | Resources | Work |
| --- | --- | --- | --- | --- | --- | --- | --- | --- | --- | --- | --- |
| 31 | 1.2.4 | **Related Hall Modifications** |  | 137d? | 2013-03-18 | 2013-09-24 |  | 29d |  |  | 56h |
| 32 | 1.2.4.1 | **PPS** |  | 137d? | 2013-03-18 | 2013-09-24 |  | 29d |  |  | 56h |
| 33 | 1.2.4.1.1 | Design |  | 1d? | 2013-03-18 | 2013-03-18 | 14 | 161d | 0d | CMc | 8h |
| 34 | 1.2.4.1.2 | Approval |  | 1d? | 2013-03-19 | 2013-03-19 | 33 | 161d | 0d | ISIS | 8h |
| 35 | 1.2.4.1.3 | Purchase |  | 1d? | 2013-03-20 | 2013-03-20 | 34 | 161d | 132d | CMc | 8h |
| 36 | 1.2.4.1.4 | Installation |  | 1d? | 2013-09-23 | 2013-09-23 | 30, 35 | 29d | 0d | CMc; Hall | 16h |
| 37 | 1.2.4.1.5 | Commisioning Test and Approval |  | 1d | 2013-09-24 | 2013-09-24 | 36 | 29d |  | CMc; ISIS | 16h |
| 38 | 1.2.5 | South Mezz A/C |  | 30d | 2013-03-18 | 2013-04-26 | 14 | 136d |  | JG | 240h |
| 39 | 1.2.6 | Sign Off / Complete | milestone | 0d | 2012-10-22 | 2012-10-22 |  | 271d |  |  |  |
| 40 | 1.2.7 | **Compressor Services (infrastructure)** |  | 251d? | 2012-10-22 | 2013-10-07 |  | 20d |  |  | 184h |
| 41 | 1.2.7.1 | Redesign of services for west wall |  | 1d? | 2013-03-18 | 2013-03-18 | 14 | 133d | 0d | IM; JW | 16h |
| 42 | 1.2.7.2 | Scheduled run with South Mezz compressors? |  | 1d? | 2012-10-22 | 2012-10-22 |  | 269d | 104d |  |  |
| 43 | 1.2.7.3 | Removal of power infrastructure from South wall |  | 1d? | 2013-03-18 | 2013-03-18 | 14, 42 | 165d |  | IM; JW; Hall | 24h |
| 44 | 1.2.7.4 | Purchase of new services |  | 1d? | 2013-03-19 | 2013-03-19 | 41 | 133d |  | IM; JW; Hall | 24h |
| 45 | 1.2.7.5 | Compressor power installation |  | 1d? | 2013-09-23 | 2013-09-23 | 30, 44 | 0d |  | IM; JW; Hall | 24h |
| 46 | 1.2.7.6 | Compressor / Vacuum control rack |  | 1d? | 2013-09-24 | 2013-09-24 | 45 | 0d |  | IM; JW; Hall | 24h |
| 47 | 1.2.7.7 | Compressor water services removal from trench |  | 3d? | 2013-09-25 | 2013-09-27 | 46 | 0d |  | JG | 24h |
| 48 | 1.2.7.8 | Decision for water services location |  | 3d? | 2013-09-30 | 2013-10-02 | 47 | 0d |  | All | 24h |
| 49 | 1.2.7.9 | Compressor water services installation |  | 3d? | 2013-10-03 | 2013-10-07 | 48 | 0d |  | JG | 24h |
| 50 | 1.2.7.10 | Sign Off / Complete | milestone | 0d | 2012-10-22 | 2012-10-22 |  | 271d |  |  |  |
| 51 | 1.2.8 | **Compressor & Services (feed) Support** |  | 161d | 2013-03-18 | 2013-10-28 | 13 | 0d |  |  | 1120h |
| 52 | 1.2.8.1 | Manufacture - purchase of parts |  | 60d | 2013-03-18 | 2013-06-07 | 14 | 76d | 75d | JT; OM | 960h |
| 53 | 1.2.8.2 | Install Hose - Power Management Structure |  | 5d | 2013-09-23 | 2013-09-27 | 30, 52 | 1d | 0d | Hall | 40h |
| 54 | 1.2.8.3 | Install Compressor Supports |  | 5d | 2013-10-08 | 2013-10-14 | 49, 53 | 0d |  | Hall | 40h |
| 55 | 1.2.8.4 | Wire Up Isolators in Stands |  | 10d | 2013-10-15 | 2013-10-28 | 54 | 0d |  | Hall | 80h |
| 56 | 1.2.8.5 | Sign Off / Complete | milestone | 0d | 2013-10-28 | 2013-10-28 | 55 | 0d |  | JT |  |

| ID | WBS | Task | Type | Duration | Start | Finish | Predecessors | Total slack | Free slack | Resources | Work |
| --- | --- | --- | --- | --- | --- | --- | --- | --- | --- | --- | --- |
| 57 | 1.2.9 | **Compressor & services installation & commisioning** |  | 26d | 2013-09-30 | 2013-11-04 |  | 0d |  |  | 240h |
| 58 | 1.2.9.1 | Installation of AFC Compressors x3 (2 helium, 1 Hydrogen) |  | 5d | 2013-10-29 | 2013-11-04 | 56 | 0d |  | Hall | 40h |
| 59 | 1.2.9.2 | Run high pressure hoses for AFC heads |  | 5d | 2013-09-30 | 2013-10-04 | 53 | 1d | 0d | Hall | 40h |
| 60 | 1.2.9.3 | Commisioning |  | 20d | 2013-10-07 | 2013-11-01 | 59 | 1d | 0d | ? | 160h |
| 61 | 1.2.9.4 | Sign Off / Complete | milestone | 0d | 2013-11-01 | 2013-11-01 | 60 | 1d |  |  |  |
| 62 | 1.2.9.5 | Complete | milestone | 0d | 2013-11-04 | 2013-11-04 | 58, 61 | 0d |  |  |  |
| 63 | 1.3 | **New MLCR & rack room** |  | 139d | 2012-10-22 | 2013-05-02 |  | 132d |  |  | 2272h |
| 64 | 1.3.1 | **Design** |  | 61d | 2012-10-22 | 2013-01-14 |  | 132d |  |  | 664h |
| 65 | 1.3.1.1 | Concept Design |  | 5d | 2012-10-22 | 2012-10-26 |  | 132d | 0d | JW; JT | 80h |
| 66 | 1.3.1.2 | 3D Model (detail) |  | 15d | 2012-10-29 | 2012-11-16 | 65 | 132d | 0d | LF; JT | 240h |
| 67 | 1.3.1.3 | Rack and workstation layout drawings |  | 3d | 2012-11-19 | 2012-11-21 | 66 | 164d | 0d | LF | 24h |
| 68 | 1.3.1.4 | Services instalation drawings |  | 5d | 2012-11-22 | 2012-11-28 | 67 | 243d |  | JW | 40h |
| 69 | 1.3.1.5 | Services management drawings |  | 5d | 2012-11-22 | 2012-11-28 | 67 | 164d | 32d | LF | 40h |
| 70 | 1.3.1.6 | Buildings Drawings |  | 30d | 2012-11-19 | 2012-12-28 | 66 | 132d | 0d | BPG | 240h |
| 71 | 1.3.1.7 | Experimental Halls Commitee Approval |  | 10d | 2012-12-31 | 2013-01-11 | 70 | 211d |  |  |  |
| 72 | 1.3.1.8 | SHE Approval |  | 10d | 2012-12-31 | 2013-01-11 | 70 | 132d | 0d |  |  |
| 73 | 1.3.1.9 | TB Approval |  | 1d | 2013-01-14 | 2013-01-14 | 69, 72 | 132d | 0d |  |  |
| 74 | 1.3.1.10 | Complete | milestone | 0d | 2013-01-14 | 2013-01-14 | 73 | 132d | 0d |  |  |
| 75 | 1.3.2 | **Buildings Work (MLCR)** |  | 105d | 2012-10-22 | 2013-03-15 |  | 166d |  |  | 744h |
| 76 | 1.3.2.1 | RFQ |  | 10d | 2012-10-22 | 2012-11-02 |  | 166d | 0d | BPG | 80h |
| 77 | 1.3.2.2 | Order |  | 3d | 2012-11-05 | 2012-11-07 | 76 | 166d | 0d | BPG | 24h |
| 78 | 1.3.2.3 | Contractor Lag |  | 30d | 2012-11-08 | 2012-12-19 | 77 | 166d | 0d |  |  |
| 79 | 1.3.2.4 | Services moves |  | 10d | 2012-12-20 | 2013-01-02 | 78 | 166d | 0d | Contractor | 80h |
| 80 | 1.3.2.5 | Door moves & install |  | 20d | 2013-01-03 | 2013-01-30 | 79 | 166d | 0d | Contractor | 160h |
| 81 | 1.3.2.6 | New signage etc |  | 2d | 2013-01-31 | 2013-02-01 | 80 | 166d | 0d | Contractor | 16h |
| 82 | 1.3.2.7 | Snagging |  | 5d | 2013-02-04 | 2013-02-08 | 81 | 166d | 0d | BPG; JT; Contractor | 120h |
| 83 | 1.3.2.8 | Office / Rack Room Builds |  | 15d | 2013-02-11 | 2013-03-01 | 82 | 166d | 0d | Contractor | 120h |
| 84 | 1.3.2.9 | False Floor Install |  | 10d | 2013-03-04 | 2013-03-15 | 83 | 166d |  | Contractor | 80h |
| 85 | 1.3.2.10 | Wall drilling to Hall |  | 3d | 2013-01-03 | 2013-01-07 | 79 | 210d | 0d | Contractor | 24h |
| 86 | 1.3.2.11 | Hall services ducts and channels |  | 5d | 2013-01-08 | 2013-01-14 | 85 | 210d | 34d | Contractor | 40h |
| 87 | 1.3.2.12 | Complete | milestone | 0d | 2013-03-01 | 2013-03-01 | 83, 86 | 176d |  |  |  |

| ID | WBS | Task | Type | Duration | Start | Finish | Predecessors | Total slack | Free slack | Resources | Work |
| --- | --- | --- | --- | --- | --- | --- | --- | --- | --- | --- | --- |
| 88 | 1.3.3 | **Services Management** |  | 50d | 2013-01-15 | 2013-03-25 |  | 132d |  |  | 640h |
| 89 | 1.3.3.1 | Order Services Management |  | 30d | 2013-01-15 | 2013-02-25 | 74 | 132d | 0d | JW; IM | 480h |
| 90 | 1.3.3.2 | Install cable tray & ductwork |  | 20d | 2013-02-26 | 2013-03-25 | 89 | 132d | 0d | Hall | 160h |
| 91 | 1.3.3.3 | Sign Off / Complete | milestone | 0d | 2013-03-25 | 2013-03-25 | 90 | 132d | 0d |  |  |
| 92 | 1.3.4 | **MLCR & Rack Room Prep** |  | 28d | 2013-03-26 | 2013-05-02 |  | 132d |  |  | 224h |
| 93 | 1.3.4.1 | Install Power & other services |  | 20d | 2013-03-26 | 2013-04-22 | 91 | 132d | 0d | Hall | 160h |
| 94 | 1.3.4.2 | Cabling and Networking |  | 5d | 2013-04-23 | 2013-04-29 | 93 | 132d | 0d | CM | 40h |
| 95 | 1.3.4.3 | Move Desks & computers |  | 2d | 2013-04-30 | 2013-05-01 | 94 | 132d | 0d | All | 16h |
| 96 | 1.3.4.4 | Commision |  | 1d | 2013-05-02 | 2013-05-02 | 95 | 132d | 0d | CM | 8h |
| 97 | 1.3.4.5 | Sign Off / Complete | milestone | 0d | 2013-05-02 | 2013-05-02 | 96 | 132d |  |  |  |
| 98 | 1.4 | **Tracker** |  | 48d? | 2012-10-22 | 2012-12-26 |  | 223d |  |  | 144h |
| 99 | 1.4.1 | **Cryostat shields** |  | 48d? | 2012-10-22 | 2012-12-26 |  | 223d |  |  | 144h |
| 100 | 1.4.1.1 | **AFE PCB 1553 transformer** |  | 18d | 2012-10-22 | 2012-11-14 |  | 253d |  |  | 32h |
| 101 | 1.4.1.1.1 | Get AFE PCB & tracker rack test set-up in new room? |  | 2d | 2012-10-22 | 2012-10-23 |  | 253d | 0d | CM | 16h |
| 102 | 1.4.1.1.2 | Evaluate sensitivity with PM |  | 1d | 2012-10-24 | 2012-10-24 | 101 | 253d | 0d | CM; DA | 16h |
| 103 | 1.4.1.1.3 | Acquire suitable shield can and mount on PCB |  | 1d | 2012-10-25 | 2012-10-25 | 102 | 253d | 0d |  |  |
| 104 | 1.4.1.1.4 | Test shield can |  | 2d | 2012-10-26 | 2012-10-29 | 103 | 253d | 0d |  |  |
| 105 | 1.4.1.1.5 | Order cans |  | 10d | 2012-10-30 | 2012-11-12 | 104 | 253d | 0d |  |  |
| 106 | 1.4.1.1.6 | Assemble cans on PCB x16+ |  | 2d | 2012-11-13 | 2012-11-14 | 105 | 253d |  |  |  |
| 107 | 1.4.1.2 | **Cold head** |  | 48d | 2012-10-22 | 2012-12-26 |  | 223d |  |  | 64h |
| 108 | 1.4.1.2.1 | Ferrous mass from Sumitomo |  | 5d | 2012-10-22 | 2012-10-26 |  | 223d | 0d |  |  |
| 109 | 1.4.1.2.2 | Rough VF model |  | 2d | 2012-10-29 | 2012-10-30 | 108 | 223d | 0d | PS; MC | 32h |
| 110 | 1.4.1.2.3 | Design split shielding can for motor |  | 2d | 2012-10-31 | 2012-11-01 | 109 | 223d | 0d |  |  |
| 111 | 1.4.1.2.4 | Prototype shield manufacture? |  | 15d | 2012-11-02 | 2012-11-22 | 110 | 223d | 0d |  |  |
| 112 | 1.4.1.2.5 | Set up cryo, vac & compressor test (3phase & water) |  | 3d | 2012-10-22 | 2012-10-24 |  | 244d | 0d |  |  |
| 113 | 1.4.1.2.6 | Test prototype shield with PM? |  | 2d | 2012-11-23 | 2012-11-26 | 112, 111 | 223d | 0d | CM; CP | 32h |
| 114 | 1.4.1.2.7 | How to test mag field effect on 2 stage shaft? |  | 2d | 2012-11-27 | 2012-11-28 | 112, 113 | 243d |  |  |  |
| 115 | 1.4.1.2.8 | Order shields |  | 20d | 2012-11-27 | 2012-12-24 | 113 | 223d | 0d |  |  |
| 116 | 1.4.1.2.9 | Assemble shields on cold heads x4 |  | 2d | 2012-12-25 | 2012-12-26 | 115 | 223d |  |  |  |

| ID | WBS | Task | Duration | Start | Finish | Predecessors | Total slack | Free slack | Resources | Work |
| --- | --- | --- | --- | --- | --- | --- | --- | --- | --- | --- |
| 117 | 1.4.1.3 | **Lid heater box** | 4d | 2012-10-22 | 2012-10-25 |  | 267d |  |  |  |
| 118 | 1.4.1.3.1 | Rough VF model with steel box and internal mass | 2d | 2012-10-22 | 2012-10-23 |  | 267d | 0d |  |  |
| 119 | 1.4.1.3.2 | Re-design external box as shield - electronics inside? | 2d | 2012-10-24 | 2012-10-25 | 118 | 267d |  |  |  |
| 120 | 1.4.1.3.3 | OR Move to shielded location. Turbo control location or Tracker rack? | 2d | 2012-10-24 | 2012-10-25 | 118 | 267d |  |  |  |
| 121 | 1.4.1.4 | **Turbo controller & PSU** | 2d? | 2012-10-25 | 2012-10-26 |  | 266d |  |  |  |
| 122 | 1.4.1.4.1 | Test 8M cable | 1d? | 2012-10-25 | 2012-10-25 | 112 | 266d | 0d |  |  |
| 123 | 1.4.1.4.2 | Find shielded location for these units (Tr. Rack reach?) | 1d | 2012-10-26 | 2012-10-26 | 122 | 266d |  |  |  |
| 124 | 1.4.1.5 | CCG vacuum gauge | 1d? | 2012-10-22 | 2012-10-22 |  | 270d |  |  |  |
| 125 | 1.4.1.6 | Wiener PSU | 1d? | 2012-10-22 | 2012-10-22 |  | 270d |  |  |  |
| 126 | 1.4.1.7 | Backing pump | 1d? | 2012-10-22 | 2012-10-22 |  | 270d |  |  |  |
| 127 | 1.4.1.8 | Turbo pump | 1d? | 2012-10-22 | 2012-10-22 |  | 270d |  | VF; TW | 16h |
| 128 | 1.4.1.9 | Vac power fail solenoid | 1d? | 2012-10-22 | 2012-10-22 |  | 270d |  | VF; TW | 16h |
| 129 | 1.4.1.10 | Compressor | 1d? | 2012-10-22 | 2012-10-22 |  | 270d |  | JT; IM | 16h |
| 130 | 1.4.2 | **Other Tracker shields** | 1d? | 2012-10-22 | 2012-10-22 |  | 270d |  |  |  |
| 131 | 1.4.2.1 | Vesda | 1d? | 2012-10-22 | 2012-10-22 |  | 270d |  |  |  |
| 132 | 1.4.2.2 | UKUS mains transformer | 1d? | 2012-10-22 | 2012-10-22 |  | 270d |  |  |  |
| 133 | 1.5 | **Racks** | 1d? | 2012-10-22 | 2012-10-22 |  | 270d |  |  |  |
| 134 | 1.5.1 | **Tracker** | 1d? | 2012-10-22 | 2012-10-22 |  | 270d |  |  |  |
| 135 | 1.5.1.1 | Cost/Benefit to extend VLSB cables | 1d? | 2012-10-22 | 2012-10-22 |  | 270d |  |  |  |
| 136 | 1.5.1.2 | Decide location | 1d? | 2012-10-22 | 2012-10-22 |  | 270d |  |  |  |
| 137 | 1.5.1.3 | Model | 1d? | 2012-10-22 | 2012-10-22 |  | 270d |  |  |  |
| 138 | 1.5.1.4 | Shield? | 1d? | 2012-10-22 | 2012-10-22 |  | 270d |  |  |  |
| 139 | 1.5.2 | **HV** | 1d? | 2012-10-22 | 2012-10-22 |  | 270d |  |  |  |
| 140 | 1.5.2.1 | Model | 1d? | 2012-10-22 | 2012-10-22 |  | 270d |  |  |  |
| 141 | 1.5.2.2 | Move to rack room or shield or both? | 1d? | 2012-10-22 | 2012-10-22 |  | 270d |  |  |  |
| 142 | 1.5.2.3 | Organise move, connect & test? | 1d? | 2012-10-22 | 2012-10-22 |  | 270d |  |  |  |

| ID | WBS | Task | Duration | Start | Finish | Total slack |
| --- | --- | --- | --- | --- | --- | --- |
| 143 | 1.6 | **Power Supply** | 1d? | 2012-10-22 | 2012-10-22 | 270d |
| 144 | 1.6.1 | **Substation 25** | 1d? | 2012-10-22 | 2012-10-22 | 270d |
| 145 | 1.6.1.1 | Analyse content & model | 1d? | 2012-10-22 | 2012-10-22 | 270d |
| 146 | 1.6.2 | **Trench transformer** | 1d? | 2012-10-22 | 2012-10-22 | 270d |
| 147 | 1.6.2.1 | Analyse content & model | 1d? | 2012-10-22 | 2012-10-22 | 270d |
| 148 | 1.6.3 | **Magnet power supplies** | 1d? | 2012-10-22 | 2012-10-22 | 270d |
| 149 | 1.6.3.1 | Analyse content & model | 1d? | 2012-10-22 | 2012-10-22 | 270d |
| 150 | 1.6.4 | **Distribution boards** | 1d? | 2012-10-22 | 2012-10-22 | 270d |
| 151 | 1.6.4.1 | Analyse content & model | 1d? | 2012-10-22 | 2012-10-22 | 270d |
| 152 | 1.6.4.2 | Decide which units at risk? | 1d? | 2012-10-22 | 2012-10-22 | 270d |
| 153 | 1.6.5 | **Consumer unit MCB/RCD issues** | 1d? | 2012-10-22 | 2012-10-22 | 270d |
| 154 | 1.6.5.1 | Analyse content & model | 1d? | 2012-10-22 | 2012-10-22 | 270d |
| 155 | 1.6.5.2 | Test in AFC field? | 1d? | 2012-10-22 | 2012-10-22 | 270d |
| 156 | 1.6.5.3 | Decide which units at risk? | 1d? | 2012-10-22 | 2012-10-22 | 270d |
| 157 | 1.7 | **Cooling channel** | 1d? | 2012-10-22 | 2012-10-22 | 270d |
| 158 | 1.7.1 | **Spectrometer solenoid** | 1d? | 2012-10-22 | 2012-10-22 | 270d |
| 159 | 1.7.1.1 | Cryocoolers | 1d? | 2012-10-22 | 2012-10-22 | 270d |
| 160 | 1.7.2 | AFC | 1d? | 2012-10-22 | 2012-10-22 | 270d |
| 161 | 1.7.3 | RF | 1d? | 2012-10-22 | 2012-10-22 | 270d |
| 162 | 1.8 | **Detectors** | 1d? | 2012-10-22 | 2012-10-22 | 270d |
| 163 | 1.8.1 | **KL** | 1d? | 2012-10-22 | 2012-10-22 | 270d |
| 164 | 1.8.1.1 | Gather info & model? | 1d? | 2012-10-22 | 2012-10-22 | 270d |
| 165 | 1.8.2 | **EMR** | 1d? | 2012-10-22 | 2012-10-22 | 270d |
| 166 | 1.8.2.1 | Gather info & model? | 1d? | 2012-10-22 | 2012-10-22 | 270d |

| ID | WBS | Task | Duration | Start | Finish | Predecessors | Total slack |
| --- | --- | --- | --- | --- | --- | --- | --- |
| 167 | 1.8.3 | **TOF** | 1d? | 2012-10-22 | 2012-10-22 |  | 270d |
| 168 | 1.8.3.1 | Gather info & model? | 1d? | 2012-10-22 | 2012-10-22 |  | 270d |
| 169 | 1.9 | **Equipment** | 1d? | 2012-10-22 | 2012-10-22 |  | 270d |
| 170 | 1.9.1 | **Vacuum pumps** | 1d? | 2012-10-22 | 2012-10-22 |  | 270d |
| 171 | 1.9.1.1 | Model | 1d? | 2012-10-22 | 2012-10-22 |  | 270d |
| 172 | 1.9.1.2 | Test sensitivity? | 1d? | 2012-10-22 | 2012-10-22 |  | 270d |
| 173 | 1.9.2 | **PPS** | 1d? | 2012-10-22 | 2012-10-22 |  | 270d |
| 174 | 1.9.2.1 | Model | 1d? | 2012-10-22 | 2012-10-22 |  | 270d |
| 175 | 1.9.2.2 | Test sensitivity? | 1d? | 2012-10-22 | 2012-10-22 |  | 270d |
| 176 | 1.9.3 | **Linde Fridge** | 1d? | 2012-10-22 | 2012-10-22 |  | 270d |
| 177 | 1.9.3.1 | Model | 1d? | 2012-10-22 | 2012-10-22 |  | 270d |
| 178 | 1.9.4 | **Moving beam stop** | 1d? | 2012-10-22 | 2012-10-22 |  | 270d |
| 179 | 1.9.4.1 | Model | 1d? | 2012-10-22 | 2012-10-22 |  | 270d |
| 180 | 1.9.5 | Other? | 1d? | 2012-10-22 | 2012-10-22 |  | 270d |
| 181 | 1.10 | **Services** | 1d? | 2012-10-22 | 2012-10-22 |  | 270d |
| 182 | 1.10.1 | Fire protection | 1d? | 2012-10-22 | 2012-10-22 |  | 270d |
| 183 | 1.10.2 | Aircon units & fans | 1d? | 2012-10-22 | 2012-10-22 |  | 270d |
| 184 | 1.10.3 | Lighting | 1d? | 2012-10-22 | 2012-10-22 |  | 270d |
| 185 | 1.10.4 | Crane | 1d? | 2012-10-22 | 2012-10-22 |  | 270d |
| 186 | 1.11 | **Area study** | 5d? | 2012-10-29 | 2012-11-02 | 2 | 261d |
| 187 | 1.11.1 | Rack room | 1d? | 2012-10-29 | 2012-10-29 |  | 265d |
| 188 | 1.11.2 | MLCR? | 1d? | 2012-10-29 | 2012-10-29 |  | 265d |
| 189 | 1.11.3 | LH2 south mezz | 1d? | 2012-10-29 | 2012-10-29 |  | 265d |
| 190 | 1.11.4 | Equipment on roof | 1d? | 2012-10-29 | 2012-10-29 |  | 265d |

| ID | WBS | Task | Duration | Start | Finish | Predecessors | Total slack | Free slack |
| --- | --- | --- | --- | --- | --- | --- | --- | --- |
| 191 | 1.11.5 | **ISIS Areas** | 5d | 2012-10-29 | 2012-11-02 |  | 261d |  |
| 192 | 1.11.5.1 | LCR, Diagnostics & Plant room | 1d | 2012-10-29 | 2012-10-29 |  | 261d | 0d |
| 193 | 1.11.5.2 | ISIS beam chopper rack | 1d | 2012-10-30 | 2012-10-30 | 192 | 261d | 0d |
| 194 | 1.11.5.3 | Other Linac?, Ion source? | 1d | 2012-10-31 | 2012-10-31 | 193 | 261d | 0d |
| 195 | 1.11.5.4 | Put forward document to ISIS | 2d | 2012-11-01 | 2012-11-02 | 194 | 261d |  |
